# Miracle Workerz 2004

Schedule from MS Project, 2003-12-22 to 2004-03-03.
Dade Behring

## Calendars

- Standard: Mon-Fri 08:00-12:00, 13:00-17:00; Sat-Sun off. Exceptions (off unless hours are given): 2003-12-23 to 2003-12-26, 2003-12-30 to 2004-01-03, 2004-01-06 to 2004-01-09, 2004-01-10 to 2004-01-11 08:00-12:00, 13:00-17:00, 2004-01-13, 2004-01-18 08:00-12:00, 13:00-17:00, 2004-01-20, 2004-01-25 08:00-12:00, 13:00-17:00, 2004-01-27, 2004-02-01 08:00-12:00, 13:00-17:00, 2004-02-07 to 2004-02-08 08:00-12:00, 13:00-17:00, 2004-02-14 to 2004-02-15 08:00-12:00, 13:00-17:00, 2004-02-21 to 2004-02-22 08:00-12:00, 13:00-17:00, 2004-02-25 to 2004-02-26 08:00-12:00, 13:00-17:00, 2004-02-27, 2004-02-29 08:00-12:00, 13:00-17:00, 2004-03-02.

## Resources

| Resource |
| --- |
| Boosterz |
| Vince |
| Lou |
| Joe |
| Machine Shop |
| Drive Train Team |
| Autonomous Team |
| Electrical Team |
| Mechanical Team 1 |
| Mechanical Team 3 |
| Engineers |
| Competition Team |
| Chassis Team |
| Full Team |
| Mechanical Team 2 |
| Strategy Team |
| RC Software Team |
| FedEx |
| Delaware Metals |
| Scouting Team |

## Schedule

| ID | WBS | Task | Duration | Start | Finish | Predecessors | Baseline start | Baseline finish | Baseline duration | Total slack | Free slack | Constraint | Resources | Work |
| --- | --- | --- | --- | --- | --- | --- | --- | --- | --- | --- | --- | --- | --- | --- |
| 1 | 1 | **Drive Train Preliminary Design** | 9d | 2003-12-22 | 2004-01-16 |  | 2002-12-16 | 2003-01-09 | 10d | 39d |  |  |  | 72h |
| 2 | 1.1 | Refine Drive System Design | 8d | 2003-12-22 | 2004-01-15 |  | 2003-01-06 | 2003-01-09 | 3d | 39d | 0d |  | Drive Train Team | 64h |
| 3 | 1.2 | Complete Drivetrain drawings | 2h | 2004-01-16 | 2004-01-16 | 2 | 2002-12-16 | 2002-12-16 | 1h | 39d | 0d |  | Drive Train Team | 2h |
| 4 | 1.3 | Obtain material for Drivetrain | 2h | 2004-01-16 | 2004-01-16 | 3 | 2002-12-16 | 2002-12-16 | 1h | 39d | 0d |  | Drive Train Team | 2h |
| 5 | 1.4 | Obtain material for chassis | 2h | 2004-01-16 | 2004-01-16 | 4 | 2002-12-26 | 2002-12-26 | 1d | 39d | 0d | start no earlier than 2003-12-29 | Drive Train Team | 2h |
| 6 | 1.5 | Obtain material for cart | 2h | 2004-01-16 | 2004-01-16 | 5 | 2002-12-27 | 2003-01-05 | 3d | 39d |  |  | Drive Train Team | 2h |
| 7 | 2 | **Build Game Field and Components** | 28d | 2004-01-10 | 2004-02-12 |  | 2003-01-04 | 2003-02-10 | 25d | 17d |  |  |  | 192h |
| 8 | 2.1 | Obtain Materials for 2004 Game Components | 1d | 2004-01-10 | 2004-01-10 |  | 2003-01-04 | 2003-01-04 | 1d | 17d | 0d | start no earlier than 2004-01-10 | Boosterz | 8h |
| 9 | 2.2 | Obtain Materials for 2004 Practice Field | 1d | 2004-01-10 | 2004-01-10 | 8SS |  |  |  | 44d |  |  | Boosterz | 8h |
| 10 | 2.3 | Build 2004 Game Components | 4d | 2004-01-11 | 2004-01-15 | 8 | 2003-01-05 | 2003-01-09 | 4d | 17d | 0d |  | Boosterz | 32h |
| 11 | 2.4 | Build 2004 Practice Field | 4d | 2004-01-18 | 2004-01-22 | 10FS+1d | 2003-01-19 | 2003-01-23 | 4d | 17d | 0d |  | Boosterz | 32h |
| 12 | 2.5 | Maintain/Enhance Operator Station | 4d | 2004-01-25 | 2004-01-29 | 11FS+1d | 2003-01-26 | 2003-01-29 | 4d | 17d | 0d |  | Boosterz | 32h |
| 13 | 2.6 | Build Cart for 2004 Robot | 5d | 2004-02-01 | 2004-02-05 | 12FS+1d | 2003-01-30 | 2003-02-04 | 4d | 17d | 0d |  | Boosterz | 40h |
| 14 | 2.7 | Modify Shipping Crate for 2004 Robot | 5d | 2004-02-08 | 2004-02-12 | 13FS+2d | 2003-02-05 | 2003-02-10 | 4d | 17d |  |  | Boosterz | 40h |
| 15 | 3 | **Robot Build** | 40d | 2004-01-10 | 2004-02-24 |  |  |  |  | 0d |  |  |  | 2606h |
| 16 | 3.1 | **Week 1: Strategy & Design** | 6d | 2004-01-10 | 2004-01-16 |  | 2003-01-04 | 2003-01-09 | 5d | 1d | 0d |  |  | 176h |
| 17 | 3.1.1 | **Understand the Game** | 2d | 2004-01-10 | 2004-01-11 |  | 2003-01-04 | 2003-01-04 | 1d | 4d | 0d | start no earlier than 2004-01-10 |  | 56h |
| 18 | 3.1.1.1 | Decide what game components are critical | 1d | 2004-01-10 | 2004-01-10 |  | 2003-01-04 | 2003-01-04 | 1d | 5d |  |  | Full Team | 8h |
| 19 | 3.1.1.2 | 4 Concurrent Divergent Brainstorming Sessions | 2d | 2004-01-10 | 2004-01-11 |  | 2003-01-04 | 2003-01-05 | 2d | 4d |  |  | Full Team | 16h |
| 20 | 3.1.1.3 | List Important Game Strategies | 2d | 2004-01-10 | 2004-01-11 |  | 2003-01-04 | 2003-01-05 | 2d | 4d |  |  | Full Team | 16h |
| 21 | 3.1.1.4 | Monitor Chief Delphi Discussions | 2d | 2004-01-10 | 2004-01-11 |  |  |  |  | 4d |  |  | Full Team | 16h |
| 22 | 3.1.2 | **Select Preliminary Game Strategy** | 3d | 2004-01-11 | 2004-01-14 | 17SS+1d | 2003-01-05 | 2003-01-06 | 2d | 1d | 0d |  |  | 96h |
| 23 | 3.1.2.1 | Convergent Brainstorming Session | 2d | 2004-01-11 | 2004-01-12 |  | 2003-01-05 | 2003-01-06 | 2d | 2d |  |  | Full Team | 16h |
| 24 | 3.1.2.2 | Determine components of concept needed to play the game | 1d | 2004-01-11 | 2004-01-11 |  | 2003-01-05 | 2003-01-05 | 1d | 1d | 0d |  | Full Team | 8h |
| 25 | 3.1.2.3 | Threat team tries to defeat our strategy | 3d | 2004-01-11 | 2004-01-14 |  |  |  |  | 1d |  |  | Strategy Team | 24h |
| 26 | 3.1.2.4 | Discuss Pros & Cons of Design | 2d | 2004-01-12 | 2004-01-14 | 24 | 2003-01-06 | 2003-01-08 | 2d | 1d |  |  | Full Team | 16h |
| 27 | 3.1.2.5 | Select a Robot Type | 1d | 2004-01-12 | 2004-01-12 | 24 | 2003-01-06 | 2003-01-06 | 1d | 1d | 0d |  | Full Team | 8h |
| 28 | 3.1.2.6 | Figure out Likely Strategys other teams will use | 1d | 2004-01-14 | 2004-01-14 | 27 | 2003-01-08 | 2003-01-08 | 1d | 1d |  |  | Full Team | 8h |
| 29 | 3.1.2.7 | How will our Strategy work with Others' | 1d | 2004-01-14 | 2004-01-14 | 27 | 2003-01-08 | 2003-01-08 | 1d | 1d |  |  | Full Team | 8h |
| 30 | 3.1.2.8 | Analyze Our Weak Points | 1d | 2004-01-14 | 2004-01-14 | 27 | 2003-01-08 | 2003-01-08 | 1d | 1d |  |  | Full Team | 8h |

| ID | WBS | Task | Type | Duration | Start | Finish | Predecessors | Baseline start | Baseline finish | Baseline duration | Total slack | Free slack | Resources | Work |
| --- | --- | --- | --- | --- | --- | --- | --- | --- | --- | --- | --- | --- | --- | --- |
| 31 | 3.1.3 | **Select Final Game Strategy** |  | 1d | 2004-01-15 | 2004-01-15 | 22 | 2003-01-08 | 2003-01-08 | 1d | 1d | 0d |  | 8h |
| 32 | 3.1.3.1 | Decide on Robot Concept based on criteria to implement our strategy |  | 1d | 2004-01-15 | 2004-01-15 |  | 2003-01-08 | 2003-01-08 | 1d | 1d | 0d | Full Team | 8h |
| 33 | 3.1.3.2 | Game Strategy Selected & Agreed Upon | milestone | 0d | 2004-01-15 | 2004-01-15 | 32 | 2003-01-08 | 2003-01-08 | 0d | 1d |  | Full Team |  |
| 34 | 3.1.3.3 | Basic Robot Design Selected & Agreed Upon | milestone | 0d | 2004-01-15 | 2004-01-15 | 32 | 2003-01-08 | 2003-01-08 | 0d | 1d |  | Full Team |  |
| 35 | 3.1.4 | **Subteams Selected and Working** |  | 1d | 2004-01-15 | 2004-01-15 | 22 |  |  |  | 1d | 0d |  | 8h |
| 36 | 3.1.4.1 | Assign Team Members to Sub-Teams |  | 1d | 2004-01-15 | 2004-01-15 |  | 2003-01-09 | 2003-01-09 | 1d | 1d |  | Full Team | 8h |
| 37 | 3.1.5 | Engineering Design Review |  | 1d | 2004-01-16 | 2004-01-16 | 17, 22, 31, 35 | 2003-01-09 | 2003-01-09 | 0d | 1d |  | Engineers | 8h |
| 38 | 3.2 | **Autonomous Programming** |  | 32d | 2004-01-18 | 2004-02-22 | 16 |  |  |  | 2d |  |  | 256h |
| 39 | 3.2.1 | Prototype Autonomous Drive Program |  | 3d | 2004-01-18 | 2004-01-21 |  | 2003-01-09 | 2003-01-13 | 3d | 2d | 0d | Autonomous Team | 24h |
| 40 | 3.2.2 | Test/Refine Autonomous Drive Prototype |  | 27d | 2004-01-22 | 2004-02-20 | 39 | 2003-01-16 | 2003-01-16 | 1d | 2d | 0d | Autonomous Team | 216h |
| 41 | 3.2.3 | Final Autonomous Drive Installation |  | 2d | 2004-02-21 | 2004-02-22 | 40 | 2003-01-16 | 2003-01-16 | 0d | 2d |  | Autonomous Team | 16h |
| 42 | 3.3 | **RC Programming** |  | 32d | 2004-01-18 | 2004-02-22 | 16 |  |  |  | 2d |  |  | 256h |
| 43 | 3.3.1 | Prototype RC Drive Program |  | 3d | 2004-01-18 | 2004-01-21 |  | 2003-01-09 | 2003-01-13 | 3d | 2d | 0d | RC Software Team | 24h |
| 44 | 3.3.2 | Test RC Drive Prototype |  | 27d | 2004-01-22 | 2004-02-20 | 43 | 2003-01-16 | 2003-01-16 | 1d | 2d | 0d | RC Software Team | 216h |
| 45 | 3.3.3 | Final Adjustments to RC Drive Program |  | 1d | 2004-02-21 | 2004-02-21 | 44 | 2003-01-15 | 2003-01-15 | 1d | 2d | 0d | RC Software Team | 8h |
| 46 | 3.3.4 | Install Final RC Drive Program |  | 1d | 2004-02-22 | 2004-02-22 | 45 | 2003-01-16 | 2003-01-16 | 0d | 2d |  | RC Software Team | 8h |
| 47 | 3.4 | **Week 2: Design and Prototype** |  | 5d | 2004-01-18 | 2004-01-23 | 16 |  |  |  | 1d | 0d |  | 340h |
| 48 | 3.4.1 | **Drive Train Prototype** |  | 4d | 2004-01-18 | 2004-01-22 |  | 2003-01-06 | 2003-02-02 | 17d | 1d | 0d |  | 76h |
| 49 | 3.4.1.1 | Order Materials for Drive System |  | 4d | 2004-01-18 | 2004-01-22 |  | 2003-01-09 | 2003-01-22 | 8d | 1d |  | Drive Train Team | 32h |
| 50 | 3.4.1.2 | Build Prototype Drive System |  | 2d | 2004-01-18 | 2004-01-19 |  |  |  |  | 1d | 0d | Drive Train Team | 16h |
| 51 | 3.4.1.3 | Demonstrate proof of concept |  | 0.5d | 2004-01-21 | 2004-01-21 | 50 |  |  |  | 1d | 0d | Drive Train Team | 4h |
| 52 | 3.4.1.4 | Final Prototype drive System |  | 1.5d | 2004-01-21 | 2004-01-22 | 51 | 2003-01-15 | 2003-01-16 | 2d | 1d |  | Drive Train Team | 12h |
| 53 | 3.4.1.5 | Select Motors |  | 1.5d | 2004-01-21 | 2004-01-22 | 51 | 2003-01-08 | 2003-01-08 | 1d | 1d |  | Drive Train Team | 12h |
| 54 | 3.4.2 | **Mechanical Prototype** |  | 4d | 2004-01-18 | 2004-01-22 |  | 2003-01-06 | 2003-01-16 | 7d | 1d | 0d |  | 88h |
| 55 | 3.4.2.1 | Build Prototype of Component 1 |  | 3d | 2004-01-18 | 2004-01-21 | 34 | 2003-01-09 | 2003-01-13 | 3d | 1d | 0d | Mechanical Team 1 | 24h |
| 56 | 3.4.2.2 | Build Prototype of Component 2 |  | 3d | 2004-01-18 | 2004-01-21 | 34 |  |  |  | 2d |  | Mechanical Team 2 | 24h |
| 57 | 3.4.2.3 | Build Prototype of Component 3 |  | 4d | 2004-01-18 | 2004-01-22 | 34 |  |  |  | 1d |  | Mechanical Team 3 | 32h |
| 58 | 3.4.2.4 | Build Prototype Electrical Panel |  | 1d | 2004-01-22 | 2004-01-22 | 55 | 2003-01-09 | 2003-01-13 | 3d | 1d |  | Electrical Team | 8h |
| 59 | 3.4.2.5 | Determine Preliminary Electrical Needs |  | 1d | 2004-01-22 | 2004-01-22 | 55 |  |  |  | 1d |  |  |  |

| ID | WBS | Task | Duration | Start | Finish | Predecessors | Baseline start | Baseline finish | Baseline duration | Total slack | Free slack | Resources | Work |
| --- | --- | --- | --- | --- | --- | --- | --- | --- | --- | --- | --- | --- | --- |
| 60 | 3.4.3 | **Create Prototype Electrical Panel** | 4d | 2004-01-18 | 2004-01-22 |  | 2003-01-19 | 2003-01-28 | 7d | 1d | 0d |  | 88h |
| 61 | 3.4.3.1 | Preliminary Functional Electrical Specs due from all teams | 1d | 2004-01-18 | 2004-01-18 |  | 2003-01-19 | 2003-01-19 | 1d | 1d | 0d | Drive Train Team; Mechanical Team 3; Mechanical Team 1; Electrical Team; Mechanical Team 2 | 40h |
| 62 | 3.4.3.2 | Prepare Electrical Panel Schematic Drawing | 2d | 2004-01-19 | 2004-01-21 | 61 |  |  |  | 1d | 0d | Electrical Team | 16h |
| 63 | 3.4.3.3 | Order needed electrical materials | 1d | 2004-01-22 | 2004-01-22 | 62 |  |  |  | 1d |  | Electrical Team | 8h |
| 64 | 3.4.3.4 | Design Electrical Components | 3d | 2004-01-19 | 2004-01-22 | 61 | 2003-01-19 | 2003-01-22 | 3d | 1d |  | Electrical Team | 24h |
| 65 | 3.4.4 | **Prepare Initial Chassis Drawings** | 4d | 2004-01-18 | 2004-01-22 |  | 2003-01-16 | 2003-01-16 | 1d | 1d | 0d |  | 64h |
| 66 | 3.4.4.1 | Evaluate Feasibility of Prototypes | 4d | 2004-01-18 | 2004-01-22 |  |  |  |  | 1d |  | Chassis Team; Vince | 64h |
| 67 | 3.4.5 | **Engineering Design Review** | 1d | 2004-01-23 | 2004-01-23 | 48, 54, 60, 65 | 2003-01-15 | 2003-01-15 | 0d | 1d |  |  | 24h |
| 68 | 3.4.5.1 | Estimate Volume of Components | 1d | 2004-01-23 | 2004-01-23 |  | 2003-01-15 | 2003-01-15 | 1d | 1d |  | Engineers | 8h |
| 69 | 3.4.5.2 | Estimate Weight of Components | 1d | 2004-01-23 | 2004-01-23 |  | 2003-01-15 | 2003-01-15 | 1d | 1d |  | Engineers | 8h |
| 70 | 3.4.5.3 | Evaluate Full Prototype | 1d | 2004-01-23 | 2004-01-23 |  | 2003-01-15 | 2003-01-15 | 1d | 1d |  | Engineers | 8h |
| 71 | 3.5 | **Week 3: Build Components** | 5d | 2004-01-25 | 2004-01-30 | 47 |  |  |  | 1d | 0d |  | 602h |
| 72 | 3.5.1 | **Build Chassis** | 5d | 2004-01-25 | 2004-01-30 |  |  |  |  | 1d |  |  | 186h |
| 73 | 3.5.1.1 | Finalize Design | 1d | 2004-01-25 | 2004-01-25 |  | 2003-01-15 | 2003-01-15 | 1d | 5d |  | Drive Train Team; Mechanical Team 3; Mechanical Team 1; Electrical Team; Chassis Team; Mechanical Team 2 | 48h |
| 74 | 3.5.1.2 | Determine Final Sub-Team Structural Needs | 1d | 2004-01-25 | 2004-01-25 |  | 2003-01-15 | 2003-01-15 | 1d | 5d |  | Drive Train Team; Mechanical Team 3; Mechanical Team 1; Electrical Team; Chassis Team; Mechanical Team 2 | 48h |
| 75 | 3.5.1.3 | Prepare Preliminary Bill of Materials | 1d | 2004-01-25 | 2004-01-25 |  | 2003-01-15 | 2003-01-15 | 1d | 5d |  | Drive Train Team; Mechanical Team 3; Mechanical Team 1; Electrical Team; Chassis Team; Mechanical Team 2 | 48h |
| 76 | 3.5.1.4 | Prepare Final Chassis Drawings | 1d | 2004-01-25 | 2004-01-25 |  | 2003-01-16 | 2003-01-16 | 1d | 1d | 0d | Vince | 8h |
| 77 | 3.5.1.5 | Final Drawing Due | 1h | 2004-01-26 | 2004-01-26 | 76 | 2003-01-16 | 2003-01-16 | 0d | 4.88d |  | Vince | 1h |
| 78 | 3.5.1.6 | Deliver Chassis Drawings to machine shop | 1h | 2004-01-26 | 2004-01-26 | 76 | 2003-01-19 | 2003-01-19 | 1h | 4.88d |  | Vince | 1h |
| 79 | 3.5.1.7 | Build First Chassis | 4d | 2004-01-26 | 2004-01-30 | 76 | 2003-01-19 | 2003-01-26 | 5d | 1d | 0d | Delaware Metals | 32h |
| 80 | 3.5.2 | **Build Drive System** | 4d | 2004-01-25 | 2004-01-29 |  |  |  |  | 1d | 0d |  | 152h |
| 81 | 3.5.2.1 | Prepare Final Drive System BOM | 4d | 2004-01-25 | 2004-01-29 |  | 2003-01-16 | 2003-01-16 | 1d | 1d |  | Drive Train Team | 32h |
| 82 | 3.5.2.2 | Order Final Drive System Materials | 4d | 2004-01-25 | 2004-01-29 |  | 2003-01-16 | 2003-01-16 | 1d | 1d |  | Drive Train Team | 32h |
| 83 | 3.5.2.3 | Final Design drive System | 1d | 2004-01-25 | 2004-01-25 |  | 2003-01-09 | 2003-01-13 | 3d | 4d |  | Drive Train Team | 8h |
| 84 | 3.5.2.4 | Modify Bosch Motors | 1d | 2004-01-25 | 2004-01-25 | 53 | 2003-01-13 | 2003-01-13 | 1d | 1d | 0d | Drive Train Team | 8h |
| 85 | 3.5.2.5 | Fabricate First Set of Transmissions | 3d | 2004-01-26 | 2004-01-29 | 84 | 2003-01-06 | 2003-01-12 | 4d | 1d |  | Machine Shop | 24h |
| 86 | 3.5.2.6 | Fabricate First Set of Wheels | 3d | 2004-01-26 | 2004-01-29 | 84 | 2003-01-06 | 2003-01-12 | 4d | 1d |  | Machine Shop | 24h |
| 87 | 3.5.2.7 | Fabricate parts for First drive system | 3d | 2004-01-26 | 2004-01-29 | 84 | 2003-01-06 | 2003-01-12 | 4d | 1d |  | Drive Train Team | 24h |

| ID | WBS | Task | Duration | Start | Finish | Predecessors | Baseline start | Baseline finish | Baseline duration | Total slack | Free slack | Resources | Work |
| --- | --- | --- | --- | --- | --- | --- | --- | --- | --- | --- | --- | --- | --- |
| 88 | 3.5.3 | **Build Mechanical Components** | 4d | 2004-01-25 | 2004-01-29 |  | 2003-01-16 | 2003-02-09 | 16d | 1d | 0d |  | 160h |
| 89 | 3.5.3.1 | Prepare Final BOM for Mechanical Components | 1d | 2004-01-25 | 2004-01-25 |  | 2003-01-16 | 2003-01-16 | 1d | 4d |  | Electrical Team; Mechanical Team 3; Mechanical Team 1; Drive Train Team | 32h |
| 90 | 3.5.3.2 | Order Materials for Final Mechanical Components | 1d | 2004-01-25 | 2004-01-25 |  | 2003-01-16 | 2003-01-16 | 1d | 4d |  | Electrical Team; Mechanical Team 3; Mechanical Team 1; Drive Train Team | 32h |
| 91 | 3.5.3.3 | Prepare Drawing of Component 1 | 1d | 2004-01-25 | 2004-01-25 |  | 2003-01-16 | 2003-01-19 | 2d | 1d | 0d | Mechanical Team 1 | 8h |
| 92 | 3.5.3.4 | Prepare Drawing of Component 2 | 1d | 2004-01-25 | 2004-01-25 |  | 2003-01-16 | 2003-01-20 | 3d | 1d | 0d | Mechanical Team 2 | 8h |
| 93 | 3.5.3.5 | Prepare Drawing of Component 3 | 1d | 2004-01-25 | 2004-01-25 |  | 2003-01-16 | 2003-01-20 | 3d | 1d | 0d | Mechanical Team 3 | 8h |
| 94 | 3.5.3.6 | Prepare parts for Component 1 | 3d | 2004-01-26 | 2004-01-29 | 91 | 2003-01-16 | 2003-01-19 | 2d | 1d |  | Mechanical Team 1 | 24h |
| 95 | 3.5.3.7 | Prepare parts for Component 2 | 3d | 2004-01-26 | 2004-01-29 | 92 | 2003-01-16 | 2003-01-20 | 3d | 1d |  | Mechanical Team 2 | 24h |
| 96 | 3.5.3.8 | Prepare parts for Component 3 | 3d | 2004-01-26 | 2004-01-29 | 93 | 2003-01-16 | 2003-01-20 | 3d | 1d |  | Mechanical Team 3 | 24h |
| 97 | 3.5.4 | **Build Electrical Panel** | 4d | 2004-01-25 | 2004-01-29 |  | 2003-01-19 | 2003-01-28 | 7d | 1d | 0d |  | 96h |
| 98 | 3.5.4.1 | Determine Final Electrical Needs | 1d | 2004-01-25 | 2004-01-25 |  | 2003-01-19 | 2003-01-19 | 1d | 1d | 0d | Drive Train Team; Mechanical Team 3; Mechanical Team 1; Electrical Team; Chassis Team; Mechanical Team 2 | 48h |
| 99 | 3.5.4.2 | Prepare Final Electrical Panel Drawing | 3d | 2004-01-26 | 2004-01-29 | 98 |  |  |  | 1d |  | Electrical Team | 24h |
| 100 | 3.5.4.3 | Order needed electrical materials | 3d | 2004-01-26 | 2004-01-29 | 98 |  |  |  | 1d |  | Electrical Team | 24h |
| 101 | 3.5.5 | Engineering Design Review | 1d | 2004-01-30 | 2004-01-30 | 80, 88, 97 | 2003-01-15 | 2003-01-15 | 0d | 1d |  | Engineers | 8h |
| 102 | 3.6 | **Week 4: Component Build** | 6d | 2004-02-01 | 2004-02-06 | 71 |  |  |  | 1d | 0d |  | 224h |
| 103 | 3.6.1 | **Cosmetic** | 5d | 2004-02-01 | 2004-02-05 |  |  |  |  | 5d |  |  | 40h |
| 104 | 3.6.1.1 | Design Robot Graphics | 2d | 2004-02-01 | 2004-02-02 |  | 2003-01-16 | 2003-01-19 | 2d | 6d | 0d | Boosterz | 16h |
| 105 | 3.6.1.2 | Print Robot Graphics | 2d | 2004-02-03 | 2004-02-04 | 104 | 2003-01-20 | 2003-01-22 | 2d | 6d |  | Boosterz | 16h |
| 106 | 3.6.1.3 | Paint Chassis | 1d | 2004-02-01 | 2004-02-01 |  | 2003-01-27 | 2003-01-27 | 1d | 5d | 0d | Chassis Team | 8h |
| 107 | 3.6.1.4 | Paint Components | 4d | 2004-02-02 | 2004-02-05 | 106 |  |  |  | 5d |  |  |  |
| 108 | 3.6.2 | **Electrical Panel** | 5d | 2004-02-01 | 2004-02-05 |  | 2003-01-23 | 2003-01-28 | 4d | 4d | 0d |  | 16h |
| 109 | 3.6.2.1 | Build Electrical Panel | 3d | 2004-02-01 | 2004-02-03 |  |  |  |  | 4d | 0d |  |  |
| 110 | 3.6.2.2 | Order Spare Electrical Parts | 1d | 2004-02-04 | 2004-02-04 | 109 |  |  |  | 5d |  |  |  |
| 111 | 3.6.2.3 | Assemble Electrical Panel | 2d | 2004-02-04 | 2004-02-05 | 109 | 2003-01-30 | 2003-01-30 | 1d | 4d |  | Electrical Team | 16h |

| ID | WBS | Task | Duration | Start | Finish | Predecessors | Baseline start | Baseline finish | Baseline duration | Total slack | Free slack | Resources | Work |
| --- | --- | --- | --- | --- | --- | --- | --- | --- | --- | --- | --- | --- | --- |
| 112 | 3.6.3 | **Drive system** | 5d | 2004-02-01 | 2004-02-05 |  |  |  |  | 1d | 0d |  | 40h |
| 113 | 3.6.3.1 | Build Drive System | 2d | 2004-02-01 | 2004-02-02 |  | 2003-01-19 | 2003-01-26 | 5d | 1d | 0d | Drive Train Team | 16h |
| 114 | 3.6.3.2 | Assemble Drive System | 2d | 2004-02-03 | 2004-02-04 | 113 | 2003-01-27 | 2003-01-27 | 1d | 1d | 0d | Drive Train Team | 16h |
| 115 | 3.6.3.3 | Unit test Drive system | 1d | 2004-02-05 | 2004-02-05 | 114 |  |  |  | 1d |  | Drive Train Team | 8h |
| 116 | 3.6.4 | **Mechanical Components** | 5d | 2004-02-01 | 2004-02-05 |  |  |  |  | 2d | 0d |  | 120h |
| 117 | 3.6.4.1 | Build Component 1 | 2d | 2004-02-01 | 2004-02-02 |  | 2003-01-20 | 2003-01-27 | 5d | 4d | 0d | Mechanical Team 1 | 16h |
| 118 | 3.6.4.2 | Build Component 2 | 2d | 2004-02-01 | 2004-02-02 |  | 2003-01-22 | 2003-01-30 | 7d | 4d | 0d | Mechanical Team 2 | 16h |
| 119 | 3.6.4.3 | Build Component 3 | 2d | 2004-02-01 | 2004-02-02 |  | 2003-01-22 | 2003-02-03 | 9d | 2d | 0d | Mechanical Team 3 | 16h |
| 120 | 3.6.4.4 | Assemble Component 3 | 2d | 2004-02-03 | 2004-02-04 | 119 | 2003-02-04 | 2003-02-04 | 1d | 2d | 0d | Mechanical Team 3 | 16h |
| 121 | 3.6.4.5 | Assemble Component 2 | 2d | 2004-02-03 | 2004-02-04 | 118 | 2003-02-02 | 2003-02-02 | 1d | 4d | 0d | Mechanical Team 2 | 16h |
| 122 | 3.6.4.6 | Assemble Component 1 | 2d | 2004-02-03 | 2004-02-04 | 117 | 2003-01-28 | 2003-01-29 | 2d | 4d | 0d | Mechanical Team 1 | 16h |
| 123 | 3.6.4.7 | Test Component 3 | 1d | 2004-02-05 | 2004-02-05 | 120 | 2003-02-04 | 2003-02-04 | 1d | 4d |  | Mechanical Team 3 | 8h |
| 124 | 3.6.4.8 | Test Component 2 | 1d | 2004-02-05 | 2004-02-05 | 121 | 2003-02-02 | 2003-02-02 | 1d | 4d |  | Mechanical Team 2 | 8h |
| 125 | 3.6.4.9 | Test Component 1 | 1d | 2004-02-05 | 2004-02-05 | 122 | 2003-01-28 | 2003-01-29 | 2d | 4d |  | Mechanical Team 1 | 8h |
| 126 | 3.6.5 | **Engineering Design Review** | 1d | 2004-02-06 | 2004-02-06 | 108, 112, 116 |  |  |  | 4d |  |  | 8h |
| 127 | 3.6.5.1 | Evaluate All Components | 1d | 2004-02-06 | 2004-02-06 |  |  |  |  | 4d |  |  |  |
| 128 | 3.6.5.2 | Review Strategy & Adjust | 1d | 2004-02-06 | 2004-02-06 |  | 2003-01-27 | 2003-02-04 | 7d | 4d |  | Engineers | 8h |
| 129 | 3.7 | **Week 5: Assembly** | 7d | 2004-02-07 | 2004-02-13 | 102 |  |  |  | 4d | 0d |  | 120h |
| 130 | 3.7.1 | **Final Assembly of Robot** | 4d | 2004-02-07 | 2004-02-10 |  |  |  |  | 4d | 0d |  | 64h |
| 131 | 3.7.1.1 | Wire Electrical Board Into Robot | 4d | 2004-02-07 | 2004-02-10 |  |  |  |  | 4d |  |  |  |
| 132 | 3.7.1.2 | Assemble Components onto Chassis | 4d | 2004-02-07 | 2004-02-10 |  |  |  |  | 4d |  |  |  |
| 133 | 3.7.1.3 | Load Initial RC & Auto Software | 4d | 2004-02-07 | 2004-02-10 |  | 2003-02-03 | 2003-02-03 | 1d | 4d |  | Autonomous Team; RC Software Team | 64h |
| 134 | 3.7.2 | **Adjust and Debug Components** | 2d | 2004-02-11 | 2004-02-12 | 130 |  |  |  | 4d | 0d |  | 48h |
| 135 | 3.7.2.1 | Debug and Finalize RC & Auto Software | 2d | 2004-02-11 | 2004-02-12 |  |  |  |  | 4d |  | Autonomous Team; RC Software Team | 32h |
| 136 | 3.7.2.2 | Preliminary Driver Training | 2d | 2004-02-11 | 2004-02-12 |  |  |  |  | 4d |  | Competition Team | 16h |
| 137 | 3.7.3 | Robot Inspection and Review | 1d | 2004-02-13 | 2004-02-13 | 134 | 2003-02-04 | 2003-02-04 | 0d | 4d |  | Engineers | 8h |

| ID | WBS | Task | Type | Duration | Start | Finish | Predecessors | Baseline start | Baseline finish | Baseline duration | Total slack | Free slack | Constraint | Resources | Work |
| --- | --- | --- | --- | --- | --- | --- | --- | --- | --- | --- | --- | --- | --- | --- | --- |
| 138 | 3.8 | **Week 6: Tuning and Training** |  | 7d | 2004-02-14 | 2004-02-20 | 129 |  |  |  | 4d |  |  |  | 504h |
| 139 | 3.8.1 | Driver Training |  | 6d | 2004-02-14 | 2004-02-19 |  | 2003-02-05 | 2003-02-15 | 7d | 4d | 0d |  | Competition Team | 48h |
| 140 | 3.8.2 | Final Tuning and Testing of Components |  | 6d | 2004-02-14 | 2004-02-19 |  |  |  |  | 5d |  |  | Autonomous Team; Chassis Team; Drive Train Team; Electrical Team; Engineers; Mechanical Team 1; Mechanical Team 2; Mechanical Team 3; RC Software Team | 432h |
| 141 | 3.8.3 | Touch-up Paint of Metal Parts |  | 1d | 2004-02-20 | 2004-02-20 | 139 | 2003-02-12 | 2003-02-13 | 1d | 4d |  |  | Drive Train Team; Mechanical Team 1; Mechanical Team 3 | 24h |
| 142 | 3.9 | **Week 7: Scrimmage and Shipment** |  | 4d | 2004-02-21 | 2004-02-24 |  |  |  |  | 0d |  |  |  | 128h |
| 143 | 3.9.1 | Hold a Scrimmage |  | 1d | 2004-02-21 | 2004-02-21 |  | 2003-02-15 | 2003-02-15 | 1d | 0d |  | must start on 2004-02-21 | Full Team | 8h |
| 144 | 3.9.2 | **Prepare Robot for Shipment** |  | 2d | 2004-02-22 | 2004-02-23 | 143 |  |  |  | 0d |  |  |  | 112h |
| 145 | 3.9.2.1 | Touch-up Paint of Metal Parts |  | 1d | 2004-02-22 | 2004-02-22 |  | 2003-02-16 | 2003-02-16 | 1d | 0d |  |  | Drive Train Team; Mechanical Team 1; Mechanical Team 3 | 24h |
| 146 | 3.9.2.2 | Final Adjustments |  | 2d | 2004-02-22 | 2004-02-23 | 143 | 2003-02-16 | 2003-02-17 | 2d | 1d |  |  | Drive Train Team; Mechanical Team 1; Mechanical Team 3; Electrical Team; Mechanical Team 2 | 80h |
| 147 | 3.9.2.3 | Pack Robot, Cart, and Parts into Crate |  | 1d | 2004-02-23 | 2004-02-23 | 145 | 2003-02-17 | 2003-02-17 | 1d | 0d |  |  | Boosterz | 8h |
| 148 | 3.9.3 | Robot Shipment |  | 1d | 2004-02-24 | 2004-02-24 | 147 | 2003-02-18 | 2003-02-18 | 0d | 0d |  | must finish on 2004-02-24 | FedEx | 8h |
| 149 | 4 | **Robot #2** |  | 22d | 2004-02-02 | 2004-02-23 |  |  |  |  | 1d |  |  |  | 336h |
| 150 | 4.1 | **Build Second Robot** |  | 7d | 2004-02-02 | 2004-02-08 | 79FS+1d |  |  |  | 5d |  |  |  | 216h |
| 151 | 4.1.1 | Build Second Chassis |  | 5d | 2004-02-02 | 2004-02-06 |  | 2003-01-30 | 2003-02-05 | 5d | 17d | 0d |  | Delaware Metals | 40h |
| 152 | 4.1.2 | Paint Second Chassis |  | 1d | 2004-02-07 | 2004-02-07 | 151 | 2003-01-27 | 2003-01-27 | 1d | 17d |  |  | Drive Train Team | 8h |
| 153 | 4.1.3 | Fabricate Second Set of Transmissions |  | 3d | 2004-02-06 | 2004-02-08 | 112 | 2003-01-13 | 2003-01-19 | 4d | 16d |  |  | Machine Shop | 24h |
| 154 | 4.1.4 | Fabricate Second Set of Wheels |  | 3d | 2004-02-06 | 2004-02-08 | 112 | 2003-01-13 | 2003-01-19 | 4d | 16d |  |  | Machine Shop | 24h |
| 155 | 4.1.5 | Fabricate parts for Second drive system |  | 3d | 2004-02-06 | 2004-02-08 | 112 | 2003-01-13 | 2003-01-19 | 4d | 1d | 0d |  | Drive Train Team | 24h |
| 156 | 4.1.6 | Build and Paint Second Component 3 |  | 2d | 2004-02-05 | 2004-02-06 | 120 | 2003-01-28 | 2003-01-29 | 2d | 2d | 0d |  | Mechanical Team 1 | 16h |
| 157 | 4.1.7 | Build and Paint Second Component 2 |  | 3d | 2004-02-05 | 2004-02-07 | 121 | 2003-02-02 | 2003-02-04 | 3d | 5d | 4d |  | Mechanical Team 2 | 24h |
| 158 | 4.1.8 | Build and Paint Second Component 1 |  | 4d | 2004-02-05 | 2004-02-08 | 122 | 2003-02-04 | 2003-02-09 | 4d | 9d | 8d |  | Mechanical Team 3 | 32h |
| 159 | 4.1.9 | Build Second Electrical Panel |  | 3d | 2004-02-02 | 2004-02-04 |  | 2003-01-23 | 2003-01-28 | 4d | 12d | 11d |  | Electrical Team | 24h |
| 160 | 4.2 | **Assemble Second Robot** |  | 17d | 2004-02-07 | 2004-02-23 |  | 2003-02-06 | 2003-02-16 | 7d | 1d |  |  |  | 120h |
| 161 | 4.2.1 | Component 3 Assembly |  | 1d | 2004-02-07 | 2004-02-07 | 156 | 2003-02-13 | 2003-02-13 | 1d | 2d | 1d |  | Mechanical Team 3 | 8h |
| 162 | 4.2.2 | Drive System Assembly |  | 3d | 2004-02-09 | 2004-02-11 | 155, 161 | 2003-02-06 | 2003-02-06 | 1d | 1d | 0d |  | Drive Train Team | 24h |
| 163 | 4.2.3 | Component 2 Assembly |  | 4d | 2004-02-12 | 2004-02-15 | 157, 162 | 2003-02-09 | 2003-02-10 | 2d | 1d | 0d |  | Mechanical Team 2 | 32h |
| 164 | 4.2.4 | Electrical Assembly |  | 1d | 2004-02-16 | 2004-02-16 | 159, 163 | 2003-02-12 | 2003-02-12 | 1d | 1d | 0d |  | Electrical Team | 8h |
| 165 | 4.2.5 | Component 1 Assembly |  | 3d | 2004-02-17 | 2004-02-19 | 158, 164 | 2003-02-16 | 2003-02-16 | 1d | 1d | 0d |  | Mechanical Team 1 | 24h |
| 166 | 4.2.6 | Final Electrical Assembly |  | 2d | 2004-02-22 | 2004-02-23 | 165FS+2d | 2003-02-12 | 2003-02-12 | 1d | 1d | 0d |  | Electrical Team | 16h |
| 167 | 4.2.7 | Load RC & Auto Software |  | 1d | 2004-02-23 | 2004-02-23 | 166SS+1d | 2003-02-15 | 2003-02-15 | 1d | 1d | 0d |  | Autonomous Team | 8h |
| 168 | 4.2.8 | Completed Robot #2 | milestone | 0d | 2004-02-23 | 2004-02-23 | 167 | 2003-02-16 | 2003-02-16 | 0d | 1d |  |  |  |  |

| ID | WBS | Task | Duration | Start | Finish | Predecessors | Total slack | Resources | Work |
| --- | --- | --- | --- | --- | --- | --- | --- | --- | --- |
| 169 | 5 | **Pre-Competition Activities** | 5d | 2004-02-25 | 2004-03-03 | 15, 149 | 0d |  | 400h |
| 170 | 5.1 | Additional Driver Training | 5d | 2004-02-25 | 2004-03-03 |  | 0d | Competition Team | 40h |
| 171 | 5.2 | Scouting | 5d | 2004-02-25 | 2004-03-03 |  | 0d | Scouting Team | 40h |
| 172 | 5.3 | Prepare Additional Spare Parts | 5d | 2004-02-25 | 2004-03-03 |  | 0d | Drive Train Team; Mechanical Team 3; Mechanical Team 1; Electrical Team; Chassis Team; Mechanical Team 2 | 240h |
| 173 | 5.4 | Build Moe Stix | 5d | 2004-02-25 | 2004-03-03 |  | 0d | Boosterz | 40h |
| 174 | 5.5 | Build Mascot | 5d | 2004-02-25 | 2004-03-03 |  | 0d | Boosterz | 40h |
